# ICC Schedule

Schedule from MS Project, 2008-07-01 to 2009-02-09, A marks actual dates.

## Calendars

- Standard: Mon-Sun 08:00-12:00, 13:00-17:00. Exceptions (off unless hours are given): 2008-07-19 to 2008-07-20, 2008-08-03 08:00-12:00, 13:00-17:00, 2008-09-27 to 2008-09-28 08:00-12:00, 13:00-17:00, 2008-10-18 08:00-12:00, 13:00-17:00.

## Resources

| Resource |
| --- |
| Tanya |
| Sarah |
| Sunil |
| Ed |
| Allan |
| Doug |
| Ken |
| Steve |
| All Developers |
| Bruce |
| Matt |
| Chris |

## Schedule

| ID | WBS | Task | Type | Duration | Start | Finish | Predecessors | Complete | Remaining | Total slack | Free slack | Constraint |
| --- | --- | --- | --- | --- | --- | --- | --- | --- | --- | --- | --- | --- |
| 1 | 1 | **FM Instrument Schedule (issue 8.9)** |  | 205d | 2008-07-17 A | 2009-02-09 |  | 2% | 201.03d | 0d |  |  |
| 2 | 1.1 | SMEC Test |  | 2d | 2008-07-17 A | 2008-07-18 A |  | 100% |  |  |  | finish no earlier than 2008-07-18 |
| 3 | 1.2 | SPIRE Commissioning Test |  | 1d | 2008-07-30 A | 2008-07-31 A | 2, 23 | 100% |  |  |  | finish no earlier than 2008-07-30 |
| 4 | 1.3 | SPIRE SPT |  | 3d | 2008-08-10 | 2008-08-12 | 3, 24 |  |  | 30d | 0d | start no earlier than 2008-08-10 |
| 5 | 1.4 | RMS Test |  | 3d | 2008-08-14 | 2008-08-16 | 4, 25 |  |  | 30d | 2d | finish no earlier than 2008-08-16 |
| 6 | 1.5 | SPIRE SOVT-1 |  | 7d | 2008-08-19 | 2008-08-25 | 5, 16, 26 |  |  | 28d | 0d | finish no earlier than 2008-08-25 |
| 7 | 1.6 | TB/TV |  | 26d | 2008-09-12 | 2008-10-07 | 6 |  |  | 11d | 0d | finish no earlier than 2008-10-07 |
| 8 | 1.7 | IST-2 |  | 28d | 2008-10-08 | 2008-11-04 | 7 |  |  | 11d | 0d | finish no earlier than 2008-11-01 |
| 9 | 1.8 | SOVT-2 |  | 6d | 2008-11-05 | 2008-11-10 | 8, 82, 27, 20FS+7d, 53 |  |  | 11d | 0d | finish no earlier than 2008-11-10 |
| 10 | 1.9 | SVT-2 |  | 6d | 2008-11-12 | 2008-11-17 | 9 |  |  | 10d | 8d | start no earlier than 2008-11-12 |
| 11 | 1.10 | Ship to Kourou |  | 3d | 2008-11-26 | 2008-11-28 | 10, 111 |  |  | 2d | 0d | start no earlier than 2008-11-26 |
| 12 | 1.11 | Launch Campaign |  | 70d | 2008-11-29 | 2009-02-06 | 11 |  |  | 2d |  | start no earlier than 2008-11-29 |
| 13 | 1.12 | Launch | milestone | 0d | 2009-02-09 | 2009-02-09 | 12, 65FS+60d |  |  | 0d |  | must start on 2009-02-09 |
| 14 | 2 | **Operations Team** |  | 138d? | 2008-07-15 A | 2008-12-01 |  | 9% | 125.33d? | 69d |  |  |
| 15 | 2.1 | **Operations Tests** |  | 125d | 2008-07-30 | 2008-12-01 |  |  |  | 28d |  |  |
| 16 | 2.1.1 | Prepare Detailed SOVT1 Plan |  | 20d | 2008-07-30 | 2008-08-18 | 75 |  |  | 28d | 0d | finish no earlier than 2008-08-18 |
| 17 | 2.1.2 | Prepare SOVT1 Test Report |  | 21d | 2008-08-26 | 2008-09-15 | 6 |  |  | 145d | 44d |  |
| 18 | 2.1.3 | Prepare Detailed SOVT2 Plan |  | 21d | 2008-10-15 | 2008-11-04 |  |  |  | 96d |  | finish no earlier than 2008-11-04 |
| 19 | 2.1.4 | Prepare SOVT2 Test Report |  | 21d | 2008-11-11 | 2008-12-01 | 9 |  |  | 69d |  |  |
| 20 | 2.1.5 | PV Simulations 1 |  | 12d | 2008-10-15 | 2008-10-26 | 50 |  |  | 13d | 2d | start no earlier than 2008-10-15 |
| 21 | 2.1.6 | PV Simulations 2 |  | 12d | 2008-11-18 | 2008-11-29 | 9FS+7d |  |  | 31d | 0d |  |
| 22 | 2.2 | **FM Test Procedures** |  | 72d? | 2008-07-15 A | 2008-09-26 |  | 29% | 50.95d? | 135d |  |  |
| 23 | 2.2.1 | Prepare and deliver IST Commissioning Test Scripts |  | 1d? | 2008-07-15 A | 2008-07-15 A |  | 100% |  |  |  | finish no earlier than 2008-07-18 |
| 24 | 2.2.2 | Prepare and deliver final SPT procedure |  | 18d? | 2008-07-21 A | 2008-08-07 A |  | 100% |  |  |  | finish no earlier than 2008-08-07 |
| 25 | 2.2.3 | Update of industry's TCL scripts for RMS test |  | 1d? | 2008-08-13 | 2008-08-13 | 4 |  |  | 30d | 0d | start no earlier than 2008-08-13 |
| 26 | 2.2.4 | Update and deliver SPIRE commands for SOVT1 |  | 1d? | 2008-08-13 | 2008-08-13 | 4 |  |  | 33d | 5d | finish no earlier than 2008-08-13 |
| 27 | 2.2.5 | Prepare and deliver SOVT2 procedure |  | 32d? | 2008-08-26 | 2008-09-26 |  |  |  | 50d | 39d | finish no earlier than 2008-09-26 |
| 28 | 2.2.6 | Update IUM to include Commissioning procedures |  | 12d? | 2008-09-01 | 2008-09-12 |  |  |  | 149d |  | start no earlier than 2008-09-01 |
| 29 | 2.2.7 | Delivery of flight Commissioing test scripts and IUM | milestone | 0d | 2008-09-12 | 2008-09-12 |  |  |  | 150d |  | start no earlier than 2008-09-12 |

| ID | WBS | Task | Type | Duration | Start | Finish | Predecessors | Complete | Remaining | Total slack | Free slack | Constraint |
| --- | --- | --- | --- | --- | --- | --- | --- | --- | --- | --- | --- | --- |
| 30 | 2.3 | **OBSW** |  | 41d? | 2008-08-07 | 2008-09-16 |  |  |  | 145d |  |  |
| 31 | 2.3.1 | Implement FDIR |  | 23d? | 2008-08-07 | 2008-08-29 |  |  |  | 151d | 0d | start no earlier than 2008-08-07 |
| 32 | 2.3.2 | Send update requests to IFSI |  | 1d | 2008-08-30 | 2008-08-30 | 31 |  |  | 151d | 1d |  |
| 33 | 2.3.3 | Produce formal version at IFSI |  | 5d? | 2008-09-01 | 2008-09-05 | 32 |  |  | 150d | 0d | finish no earlier than 2008-09-05 |
| 34 | 2.3.4 | Return OBSW to RAL |  | 1d | 2008-09-06 | 2008-09-06 | 33 |  |  | 150d | 5d |  |
| 35 | 2.3.5 | Final test at RAL |  | 5d | 2008-09-12 | 2008-09-16 | 34 |  |  | 145d | 0d | start no earlier than 2008-09-12 |
| 36 | 2.3.6 | Delivery to Herschel | milestone | 0d | 2008-09-16 | 2008-09-16 | 35 |  |  | 145d |  |  |
| 37 | 3 | **Calibration Team** |  | 190d | 2008-07-01 A | 2009-01-08 |  | 6% | 178.66d | 31d |  |  |
| 38 | 3.1 | **Initial Delivery** |  | 20d | 2008-07-01 A | 2008-07-23 A |  | 100% |  |  |  |  |
| 39 | 3.1.1 | Preparation of Scripts for First Delivery |  | 20d | 2008-07-01 A | 2008-07-22 A |  | 100% |  |  |  | start no earlier than 2008-07-01 |
| 40 | 3.1.2 | First delivery of PV phase observations | milestone | 0d | 2008-07-23 A | 2008-07-23 A | 39 | 100% |  |  |  | start no earlier than 2008-07-23 |
| 41 | 3.2 | **PV Phase Simulations** |  | 89d | 2008-07-01 A | 2008-09-29 |  |  | 89d | 132d |  |  |
| 42 | 3.2.1 | Delivery of Issue 1 of Calibration Observation Templates Document | milestone | 0d | 2008-08-06 A | 2008-08-06 A |  | 100% |  |  |  | start no earlier than 2008-08-06 |
| 43 | 3.2.2 | Delivery of Issue 1 of Commisioning Phase Plan | milestone | 0d | 2008-08-05 A | 2008-08-05 A |  | 100% |  |  |  | start no earlier than 2008-08-05 |
| 44 | 3.2.3 | Delivery of Issue 1 of PV Phase Plan | milestone | 0d | 2008-08-06 A | 2008-08-06 A |  | 100% |  |  |  | start no earlier than 2008-08-06 |
| 45 | 3.2.4 | Preparation of next issue of Commissioning Phase Plan |  | 5w | 2008-08-06 | 2008-08-30 | 43, 3 |  |  | 162d | 12d | start no earlier than 2008-08-06 |
| 46 | 3.2.5 | Delivery of commissioing phase plan | milestone | 0d | 2008-09-12 | 2008-09-12 | 45 |  |  | 150d |  | start no earlier than 2008-09-12 |
| 47 | 3.2.6 | Preparation of next issue of PV Phase Plan |  | 8w | 2008-08-06 | 2008-09-14 | 44 |  |  | 29d | 0d |  |
| 48 | 3.2.7 | Preparation of PV Phase scripts |  | 15w | 2008-07-01 | 2008-09-15 |  |  |  | 28d | 0d |  |
| 49 | 3.2.8 | Preparation of AORs/SSFs for PV Phase Simulations |  | 14d | 2008-09-16 | 2008-09-29 | 47, 48 |  |  | 28d | 0d |  |
| 50 | 3.2.9 | Delivery for PV Phase Simulations | milestone | 0d | 2008-09-29 | 2008-09-29 | 49 |  |  | 28d | 15d |  |
| 51 | 3.3 | **SOVT-2** |  | 14d | 2008-09-16 | 2008-09-29 |  |  |  | 47d |  |  |
| 52 | 3.3.1 | Preparation of AORs/SSFs for SOVT-2 |  | 14d | 2008-09-16 | 2008-09-29 | 48 |  |  | 47d | 0d | finish no earlier than 2008-08-30 |
| 53 | 3.3.2 | Delivery for SOVT-2 | milestone | 0d | 2008-09-29 | 2008-09-29 | 52 |  |  | 47d | 36d | start no earlier than 2008-09-01 |

| ID | WBS | Task | Type | Duration | Start | Finish | Predecessors | Complete | Remaining | Total slack | Free slack | Constraint |
| --- | --- | --- | --- | --- | --- | --- | --- | --- | --- | --- | --- | --- |
| 54 | 3.4 | **PV Phase Delivery** |  | 116d | 2008-09-15 | 2009-01-08 |  |  |  | 31d |  |  |
| 55 | 3.4.1 | Update PV Phase Plan |  | 14d | 2008-09-15 | 2008-09-28 | 47 |  |  | 118d | 1d |  |
| 56 | 3.4.2 | Internal Review of PV Phase Plan |  | 14d | 2008-09-30 | 2008-10-13 | 52, 55 |  |  | 117d | 16d |  |
| 57 | 3.4.3 | Preparation of AORs/SSFs for PV Phase Final Launch Delivery |  | 40d | 2008-11-30 | 2009-01-08 | 21 |  |  | 31d | 0d | finish no earlier than 2008-12-18 |
| 58 | 3.4.4 | PV Phase Final Launch Delivery | milestone | 0d | 2009-01-08 | 2009-01-08 | 57 |  |  | 31d |  |  |
| 59 | 3.5 | **Routine Phase Plan** |  | 30d | 2008-11-01 | 2008-12-01 |  |  |  | 0d |  |  |
| 60 | 3.5.1 | Preparation of Routine Phase Plan |  | 14d | 2008-11-01 | 2008-11-14 |  |  |  | 16d |  | start no earlier than 2008-11-01 |
| 61 | 3.5.2 | Delivery of Routine Phase Plan | milestone | 0d | 2008-12-01 | 2008-12-01 | 60 |  |  | 0d |  | must start on 2008-12-01 |
| 62 | 3.6 | **Calibration File Derivation Procedures** |  | 53d | 2008-09-08 | 2008-10-30 |  |  |  | 43d |  |  |
| 63 | 3.6.1 | Preparation of Calibration File Derivation Procedures |  | 21d | 2008-09-08 | 2008-09-28 | 79 |  |  | 43d |  |  |
| 64 | 3.6.2 | Delivery of Calibration Product Derivation Procedures | milestone | 0d | 2008-10-01 | 2008-10-01 | 63 |  |  | 41d | 0d | start no earlier than 2008-10-01 |
| 65 | 3.6.3 | Review of CPDPs |  | 30d | 2008-10-01 | 2008-10-30 | 64 |  |  | 41d |  |  |
| 66 | 3.6.4 | Update of CFDPs following Scientific Validation Phase 1 |  | 14d | 2008-10-16 | 2008-10-29 | 85 |  |  | 102d |  |  |
| 67 | 4 | **Software Team** |  | 200d? | 2008-07-01 A | 2009-01-18 |  | 1% | 198.07d? | 21d |  |  |
| 68 | 4.1 | **HCSS Schedule** |  | 102d? | 2008-07-01 | 2008-10-13 |  |  |  | 119d |  |  |
| 69 | 4.1.1 | Code Freeze For HCSS v0.6.4 | milestone | 0d | 2008-09-01 | 2008-09-01 |  |  |  | 161d |  | start no earlier than 2008-09-01 |
| 70 | 4.1.2 | System Testing For HCSS 0.6.4 |  | 7d | 2008-08-18 | 2008-08-24 |  |  |  | 168d |  | finish no earlier than 2008-08-24 |
| 71 | 4.1.3 | Code Freeze For HCSS v0.6.5 | milestone | 0d | 2008-10-13 | 2008-10-13 |  |  |  | 119d |  | start no earlier than 2008-10-13 |
| 72 | 4.1.4 | System Testing For HCSS 0.6.5 |  | 5d | 2008-09-28 | 2008-10-02 |  |  |  | 129d |  | start no earlier than 2008-09-28 |
| 73 | 4.1.5 | Predicted Date of Code Freeze for HCSS 0.6.6 or 1.0 (TBD) |  | 1d? | 2008-07-01 | 2008-07-01 |  |  |  | 220d |  |  |
| 74 | 4.2 | **SPIRE DP Schedule** |  | 198d | 2008-07-03 A | 2009-01-18 |  | 1% | 195.96d | 21d |  |  |
| 75 | 4.2.1 | Acceptance Testing HCSS v0.6.3 |  | 2d | 2008-07-03 A | 2008-07-04 A |  | 100% |  |  |  | finish no earlier than 2008-07-29 |
| 76 | 4.2.2 | **Science Verification Phase 1** |  | 76d | 2008-08-01 A | 2008-10-15 |  |  | 76d | 116d |  |  |
| 77 | 4.2.2.1 | Top Level Documents Released | milestone | 0d | 2008-08-01 A | 2008-08-01 A |  | 100% |  |  |  | start no earlier than 2008-08-01 |
| 78 | 4.2.2.2 | Update of Module Requirements Document |  | 24d | 2008-08-01 | 2008-08-24 | 77 |  |  | 43d | 0d |  |
| 79 | 4.2.2.3 | Documentation Review for Scientific Validation |  | 14d | 2008-08-25 | 2008-09-07 | 78 |  |  | 43d |  |  |
| 80 | 4.2.2.4 | Writing of Detailed Test Plans for Scientific Validation |  | 14d | 2008-08-25 | 2008-09-07 | 78 |  |  | 154d |  |  |
| 81 | 4.2.2.5 | Code Freeze For SPIRE DP Verification Phase 1 | milestone | 0d | 2008-09-01 | 2008-09-01 |  |  |  | 68d | 0d | start no earlier than 2008-09-01 |
| 82 | 4.2.2.6 | Acceptance Tesrting SPIRE DP Verification Phase 1 |  | 8d | 2008-09-01 | 2008-09-08 | 81 |  |  | 68d | 0d | start no earlier than 2008-08-25 |
| 83 | 4.2.2.7 | Implemation of Updates after Acceptance Testing |  | 7d | 2008-09-09 | 2008-09-15 | 82 |  |  | 102d | 0d |  |
| 84 | 4.2.2.8 | Scientific Validation of SPIRE DP Phase 1 |  | 30d | 2008-09-16 | 2008-10-15 | 83 |  |  | 102d | 0d |  |
| 85 | 4.2.2.9 | Phase 1 Scientific Validation Reports Ready | milestone | 0d | 2008-10-15 | 2008-10-15 | 84 |  |  | 102d | 0d |  |

| ID | WBS | Task | Type | Duration | Start | Finish | Predecessors | Complete | Remaining | Total slack | Free slack | Constraint |
| --- | --- | --- | --- | --- | --- | --- | --- | --- | --- | --- | --- | --- |
| 86 | 4.2.3 | **Science Verification Phase 2** |  | 46d | 2008-10-13 | 2008-11-27 |  |  |  | 73d |  |  |
| 87 | 4.2.3.1 | Code Freeze For SPIRE DP 0.7, Verification Phase 2 | milestone | 0d | 2008-10-13 | 2008-10-13 |  |  |  | 73d | 0d | start no earlier than 2008-10-13 |
| 88 | 4.2.3.2 | Acceptance Testing of SPIRE DP Verification Phase 2 |  | 14d | 2008-10-13 | 2008-10-26 | 87 |  |  | 73d | 0d | start no earlier than 2008-10-03 |
| 89 | 4.2.3.3 | Scientific Validation of SPIRE DP Phase 2 |  | 32d | 2008-10-27 | 2008-11-27 | 88 |  |  | 73d | 0d |  |
| 90 | 4.2.3.4 | Phase 1 Scientific Validation Reports Ready | milestone | 0d | 2008-11-27 | 2008-11-27 | 89 |  |  | 73d |  |  |
| 91 | 4.2.4 | **Science Verification Phase 3** |  | 56d | 2008-11-24 | 2009-01-18 |  |  |  | 21d |  |  |
| 92 | 4.2.4.1 | Predicted Date of Code Freeze for HCSS 0.6.6 or 1.0 (TBD), SPIRE DP Version 1.0 | milestone | 0d | 2008-11-24 | 2008-11-24 |  |  |  | 21d | 0d | start no earlier than 2008-11-24 |
| 93 | 4.2.4.2 | Acceptance Testing of SPIRE DP Verification Phase 3 |  | 7d | 2008-12-01 | 2008-12-07 | 92FS+7d |  |  | 63d |  |  |
| 94 | 4.2.4.3 | Scientific Validation of SPIRE DP Phase 3 |  | 42d | 2008-12-08 | 2009-01-18 | 92FS+14d |  |  | 21d |  |  |
| 95 | 5 | **Reviews** |  | 146d? | 2008-07-01 A | 2008-11-25 |  | 1% | 144.94d? | 75d |  |  |
| 96 | 5.1 | **Ground Segment Readiness Review** |  | 108d | 2008-07-01 | 2008-10-19 |  |  |  | 113d |  |  |
| 97 | 5.1.1 | Preparation of Documents |  | 35d | 2008-07-01 | 2008-08-06 |  |  |  | 183d | 0d | start no earlier than 2008-07-01 |
| 98 | 5.1.2 | Deadline for ICC documents | milestone | 0d | 2008-08-06 | 2008-08-06 | 97, 75 |  |  | 183d | 6d | start no earlier than 2008-08-06 |
| 99 | 5.1.3 | GSRR KO Meeting |  | 2d | 2008-08-13 | 2008-08-14 | 98 |  |  | 177d | 39d | finish no earlier than 2008-08-14 |
| 100 | 5.1.4 | Final RIDs Due | milestone | 0d | 2008-09-23 | 2008-09-23 | 99 |  |  | 138d | 7d | start no earlier than 2008-09-23 |
| 101 | 5.1.5 | GSRR Board Meeting |  | 1d | 2008-09-30 | 2008-09-30 | 100 |  |  | 131d | 18d | start no earlier than 2008-09-30 |
| 102 | 5.1.6 | Report to FAR board | milestone | 0d | 2008-10-19 | 2008-10-19 | 101 |  |  | 113d |  | start no earlier than 2008-10-19 |
| 103 | 5.2 | **IFAR** |  | 78d? | 2008-07-29 A | 2008-10-15 |  | 2% | 76.66d? | 117d |  |  |
| 104 | 5.2.1 | Internal Review of SPIRE inputs |  | 1d? | 2008-07-29 A | 2008-07-29 A |  | 100% |  |  |  | start no earlier than 2008-07-29 |
| 105 | 5.2.2 | Preparation of Datapack |  | 55d? | 2008-07-30 | 2008-09-22 | 104 |  |  | 137d | 0d | finish no earlier than 2008-09-22 |
| 106 | 5.2.3 | IFAR KO | milestone | 0d | 2008-09-23 | 2008-09-23 | 105 |  |  | 137d | 10d | start no earlier than 2008-09-23 |
| 107 | 5.2.4 | IFAR RIDS to PI | milestone | 0d | 2008-10-03 | 2008-10-03 | 106 |  |  | 127d | 3d | start no earlier than 2008-10-03 |
| 108 | 5.2.5 | Prepartaion of Reaction to RIDs |  | 2d? | 2008-10-06 | 2008-10-07 | 107 |  |  | 124d | 0d | finish no earlier than 2008-10-07 |
| 109 | 5.2.6 | IFAR Co-Location | milestone | 0d | 2008-10-08 | 2008-10-08 | 108 |  |  | 124d | 7d | start no earlier than 2008-10-08 |
| 110 | 5.2.7 | IFAR Board Meeting | milestone | 0d | 2008-10-15 | 2008-10-15 | 109 |  |  | 117d |  | start no earlier than 2008-10-15 |
| 111 | 5.3 | FAR |  | 41d | 2008-10-16 | 2008-11-25 |  |  |  | 2d | 0d | finish no earlier than 2008-11-25 |
| 112 | 5.4 | ICC Readiness Review |  | 1d | 2008-10-30 | 2008-10-30 | 56, 85, 17 |  |  | 101d |  | start no earlier than 2008-10-30 |
